# 发票管理软件V1.0-WBS

Schedule from MS Project, 2017-09-01 to 2017-12-05, costs in ¥, A marks actual dates.

## Calendars

- 标准: Mon-Fri 08:00-12:00, 13:00-17:00; Sat-Sun off. Exceptions (off unless hours are given): 2017-10-01 to 2017-10-08.

## Resources

| Resource | Rate |
| --- | --- |
| 客户代表 |  |
| 胡威 | 50 |
| 屈文敏 | 50 |
| 唐锦涛 | 50 |
| 项目组 | 300 |
| 评审组 | 200 |
| 李丹 | 50 |
| 彭李雪 | 50 |
| 赵世贤 | 50 |
| 潘丹 | 50 |
| 用户代表 |  |
| 0 |  |

## Schedule

| ID | WBS | Task | Type | Duration | Start | Finish | Complete | Actual finish | Baseline start | Baseline finish | Baseline duration | Resources | Work | Actual work | Cost | Baseline cost | Actual cost |
| --- | --- | --- | --- | --- | --- | --- | --- | --- | --- | --- | --- | --- | --- | --- | --- | --- | --- |
| 1 | 1 | **项目立项** |  | 1d | 2017-09-01 A | 2017-09-01 A | 100% |  | 2017-09-01 | 2017-09-01 | 1d |  | 8h | 8h | 400 | 400 | 400 |
| 2 | 1.1 | 项目立项（立项申请，立项审批，立项公告） | manual | 1d | 2017-09-01 A | 2017-09-01 A | 100% |  | 2017-09-01 | 2017-09-01 | 1d | 李丹 | 8h | 8h | 400 | 400 | 400 |
| 3 | 1.2 | 项目启动（项目章程，项目组成立） | manual | 1d | 2017-09-01 A | 2017-09-01 A | 100% |  | 2017-09-01 | 2017-09-01 | 1d |  |  |  |  |  |  |
| 4 | 2 | **项目策划阶段** |  | 2d | 2017-09-04 A | 2017-09-05 | 100% | 2017-09-06 | 2017-09-04 | 2017-09-07 | 3d |  | 48h | 48h | 2,000 | 2,400 | 2,000 |
| 5 | 2.1 | 项目过程定义裁剪 | manual | 1d | 2017-09-04 A | 2017-09-04 A | 100% |  | 2017-09-04 | 2017-09-04 | 1d | 李丹 | 8h | 8h | 400 | 400 | 400 |
| 6 | 2.2 | 构造WBS及项目估算 | manual | 2d | 2017-09-05 A | 2017-09-06 A | 100% |  | 2017-09-05 | 2017-09-07 | 2d | 李丹 [50%] | 16h | 16h | 800 | 800 | 800 |
| 7 | 2.3 | 项目计划（总体计划，质量保证计划，配置计划，测试计划，项目测量计划) | manual | 1d | 2017-09-05 A | 2017-09-05 A | 100% |  | 2017-09-05 | 2017-09-07 | 1d | 胡威; 潘丹; 屈文敏; 李丹 [50%] | 16h | 16h | 800 | 1,200 | 800 |
| 8 | 2.4 | 项目计划评审 | manual | 1d | 2017-09-06 A | 2017-09-06 A | 100% |  |  |  |  | 评审组 | 8h | 8h |  |  |  |
| 9 | 3 | **需求阶段** |  | 13d | 2017-09-06 A | 2017-09-22 A | 100% |  | 2017-09-08 | 2017-09-20 | 9d |  | 112h | 112h | 6,000 | 9,600 | 6,000 |
| 10 | 3.1 | 用户需求说明书 | manual | 4d | 2017-09-06 A | 2017-09-11 A | 100% |  | 2017-09-08 | 2017-09-14 | 4d | 李丹 | 32h | 32h | 1,600 | 1,600 | 1,600 |
| 11 | 3.2 | 软件需求说明书 | manual | 5d | 2017-09-12 A | 2017-09-18 A | 100% |  | 2017-09-08 | 2017-09-18 | 4d | 李丹 | 40h | 40h | 2,000 | 1,600 | 2,000 |
| 12 | 3.3 | 需求记录表，功能点及项目计划 | manual | 1d | 2017-09-18 A | 2017-09-18 A | 100% |  | 2017-09-08 | 2017-09-08 | 1d | 李丹 | 8h | 8h | 400 | 400 | 400 |
| 13 | 3.4 | 用户需求说明书评审会议 | manual | 1d | 2017-09-12 A | 2017-09-12 A | 100% |  | 2017-09-15 | 2017-09-15 | 1d | 评审组 | 8h | 8h |  | 1,600 |  |
| 14 | 3.5 | 软件需求说明书评审会议 | manual | 1d | 2017-09-20 A | 2017-09-20 A | 100% |  | 2017-09-19 | 2017-09-19 | 1d | 评审组 | 8h | 8h | 1,600 | 1,600 | 1,600 |
| 15 | 3.6 | 编写需求阶段里程碑报告 | manual | 1d | 2017-09-22 A | 2017-09-22 A | 100% |  | 2017-09-20 | 2017-09-20 | 1d | 李丹 | 8h | 8h | 400 | 400 | 400 |
| 16 | 3.7 | 需求阶段里程碑会议 | manual | 1d | 2017-09-22 A | 2017-09-22 A | 100% |  | 2017-09-20 | 2017-09-20 | 1d | 项目组 | 8h | 8h |  | 2,400 |  |
| 17 | 4 | **设计阶段任务** |  | 10d | 2017-09-12 A | 2017-09-25 A | 100% |  | 2017-09-15 | 2017-09-25 | 9d |  | 160h | 160h | 10,800 | 12,400 | 10,800 |
| 18 | 4.1 | **详细设计** |  | 9d | 2017-09-12 A | 2017-09-22 A | 100% |  | 2017-09-15 | 2017-09-22 | 8d |  | 136h | 136h | 6,800 | 7,200 | 6,800 |
| 19 | 4.1.1 | 详细设计说明书 | manual | 9d | 2017-09-12 A | 2017-09-22 A | 100% |  | 2017-09-15 | 2017-09-22 | 8d | 彭李雪 [80%] | 68.8h | 68.8h | 3,440 | 3,200 | 3,440 |
| 20 | 4.1.2 | 数据库设计 | manual | 7d | 2017-09-12 A | 2017-09-20 A | 100% |  | 2017-09-15 | 2017-09-20 | 5d | 赵世贤; 彭李雪 [20%] | 67.2h | 67.2h | 3,360 | 4,000 | 3,360 |
| 21 | 4.2 | 设计阶段详细设计说明书评审会议 | manual | 1d | 2017-09-25 A | 2017-09-25 A | 100% |  | 2017-09-25 | 2017-09-25 | 1d | 评审组 | 8h | 8h | 1,600 | 2,400 | 1,600 |
| 22 | 4.3 | 设计阶段详细设计里程碑报告编写 | manual | 1d | 2017-09-25 A | 2017-09-25 A | 100% |  | 2017-09-25 | 2017-09-25 | 1d | 李丹 [60%] | 8h | 8h |  | 400 |  |
| 23 | 4.4 | 设计阶段详细设计里程碑会议 | manual | 1d | 2017-09-25 A | 2017-09-25 A | 100% |  | 2017-09-25 | 2017-09-25 | 1d | 项目组 | 8h | 8h | 2,400 | 2,400 | 2,400 |
| 24 | 5 | **编码和单元测试阶段** |  | 41d | 2017-09-12 A | 2017-11-14 A | 100% |  | 2017-09-15 | 2017-10-27 | 24d |  | 824h | 824h | 43,200 | 27,200 | 43,200 |
| 25 | 5.1 | **编码** |  | 40d | 2017-09-12 A | 2017-11-13 A | 100% |  | 2017-09-15 | 2017-10-26 | 23d |  | 808h | 808h | 40,400 | 24,400 | 40,400 |
| 26 | 5.1.1 | **注册码管理** |  | 14d | 2017-09-12 A | 2017-09-29 A | 100% |  | 2017-09-15 | 2017-09-22 | 6d |  | 136h | 136h | 6,800 | 2,800 | 6,800 |
| 27 | 5.1.1.1 | 编码 | manual | 10d | 2017-09-12 A | 2017-09-25 A | 100% |  | 2017-09-15 | 2017-09-20 | 4d | 彭李雪 | 80h | 80h | 4,000 | 1,600 | 4,000 |
| 28 | 5.1.1.2 | 单元测试 | manual | 3d | 2017-09-25 A | 2017-09-27 A | 100% |  | 2017-09-21 | 2017-09-21 | 1d | 彭李雪 | 24h | 24h | 1,200 | 400 | 1,200 |
| 29 | 5.1.1.3 | 代码走查 | manual | 1d | 2017-09-28 A | 2017-09-28 A | 100% |  | 2017-09-21 | 2017-09-21 | 1d | 李丹 | 8h | 8h | 400 | 400 | 400 |
| 30 | 5.1.1.4 | 代码返工 | manual | 3d | 2017-09-27 A | 2017-09-29 A | 100% |  | 2017-09-22 | 2017-09-22 | 1d | 彭李雪 | 24h | 24h | 1,200 | 400 | 1,200 |

| ID | WBS | Task | Type | Duration | Start | Finish | Complete | Baseline start | Baseline finish | Baseline duration | Resources | Work | Actual work | Cost | Baseline cost | Actual cost |
| --- | --- | --- | --- | --- | --- | --- | --- | --- | --- | --- | --- | --- | --- | --- | --- | --- |
| 31 | 5.1.2 | **注册码类型管理** |  | 8d | 2017-09-30 A | 2017-10-18 A | 100% | 2017-09-23 | 2017-10-26 | 17d |  | 104h | 104h | 5,200 | 11,200 | 5,200 |
| 32 | 5.1.2.1 | 编码 | manual | 7d | 2017-09-30 A | 2017-10-16 A | 100% | 2017-09-23 | 2017-10-20 | 18d | 彭李雪 | 72h | 72h | 3,600 | 9,200 | 3,600 |
| 33 | 5.1.2.2 | 单元测试 | manual | 2d | 2017-10-16 A | 2017-10-17 A | 100% | 2017-10-20 | 2017-10-20 | 1d | 彭李雪 | 16h | 16h | 800 | 400 | 800 |
| 34 | 5.1.2.3 | 代码走查 | manual | 1d | 2017-10-18 A | 2017-10-18 A | 100% | 2017-10-23 | 2017-10-23 | 1d | 李丹 | 8h | 8h | 400 | 400 | 400 |
| 35 | 5.1.2.4 | 代码返工 | manual | 1d | 2017-10-18 A | 2017-10-18 A | 100% | 2017-10-23 | 2017-10-26 | 3d | 彭李雪 | 8h | 8h | 400 | 1,200 | 400 |
| 36 | 5.1.3 | **注册码上传** |  | 21d | 2017-10-16 A | 2017-11-13 A | 100% | 2017-10-09 | 2017-10-25 | 12d |  | 192h | 192h | 9,600 | 5,600 | 9,600 |
| 37 | 5.1.3.1 | 编码 | manual | 16d | 2017-10-16 A | 2017-11-04 A | 100% | 2017-10-09 | 2017-10-20 | 10d | 彭李雪 | 128h | 128h | 6,400 | 4,000 | 6,400 |
| 38 | 5.1.3.2 | 单元测试 | manual | 4d | 2017-11-05 A | 2017-11-08 A | 100% | 2017-10-21 | 2017-10-21 | 1d | 彭李雪 | 32h | 32h | 1,600 | 400 | 1,600 |
| 39 | 5.1.3.3 | 代码走查 | manual | 1d | 2017-11-09 A | 2017-11-09 A | 100% | 2017-10-23 | 2017-10-23 | 1d | 李丹 | 8h | 8h | 400 | 400 | 400 |
| 40 | 5.1.3.4 | 代码返工 | manual | 3d | 2017-11-09 A | 2017-11-13 A | 100% | 2017-10-23 | 2017-10-25 | 2d | 彭李雪 | 24h | 24h | 1,200 | 800 | 1,200 |
| 41 | 5.1.4 | **API调用** |  | 14d | 2017-09-12 A | 2017-09-30 A | 100% | 2017-09-15 | 2017-09-29 | 11d |  | 136h | 136h | 6,800 | 4,800 | 6,800 |
| 42 | 5.1.4.1 | 编码 | manual | 12d | 2017-09-12 A | 2017-09-27 A | 100% | 2017-09-15 | 2017-09-25 | 7d | 赵世贤 | 96h | 96h | 4,800 | 2,800 | 4,800 |
| 43 | 5.1.4.2 | 单元测试 | manual | 2d | 2017-09-27 A | 2017-09-28 A | 100% | 2017-09-27 | 2017-09-27 | 2d | 赵世贤 | 16h | 16h | 800 | 800 | 800 |
| 44 | 5.1.4.3 | 代码走查 | manual | 1d | 2017-09-28 A | 2017-09-28 A | 100% | 2017-09-28 | 2017-09-28 | 1d | 李丹 | 8h | 8h | 400 | 400 | 400 |
| 45 | 5.1.4.4 | 代码返工 | manual | 2d | 2017-09-29 A | 2017-09-30 A | 100% | 2017-09-29 | 2017-09-29 | 2d | 赵世贤 | 16h | 16h | 800 | 800 | 800 |
| 46 | 5.1.5 | **单据明细处理** |  | 7d | 2017-10-09 A | 2017-10-17 A | 100% |  |  |  |  | 72h | 72h | 3,600 |  | 3,600 |
| 47 | 5.1.5.1 | 编码 | manual | 5d | 2017-10-09 A | 2017-10-13 A | 100% |  |  |  | 赵世贤 | 40h | 40h | 2,000 |  | 2,000 |
| 48 | 5.1.5.2 | 单元测试 | manual | 1d | 2017-10-16 A | 2017-10-16 A | 100% |  |  |  | 赵世贤 | 8h | 8h | 400 |  | 400 |
| 49 | 5.1.5.3 | 代码走查 | manual | 1d | 2017-10-16 A | 2017-10-16 A | 100% |  |  |  | 李丹 | 8h | 8h | 400 |  | 400 |
| 50 | 5.1.5.4 | 代码返工 | manual | 2d | 2017-10-16 A | 2017-10-17 A | 100% |  |  |  | 赵世贤 | 16h | 16h | 800 |  | 800 |
| 51 | 5.1.6 | **快速开票** |  | 19d | 2017-10-17 A | 2017-11-10 A | 100% |  |  |  |  | 168h | 168h | 8,400 |  | 8,400 |
| 52 | 5.1.6.1 | 编码 | manual | 14d | 2017-10-17 A | 2017-11-03 A | 100% |  |  |  | 赵世贤 | 112h | 112h | 5,600 |  | 5,600 |
| 53 | 5.1.6.2 | 单元测试 | manual | 3d | 2017-11-06 A | 2017-11-08 A | 100% |  |  |  | 赵世贤 | 24h | 24h | 1,200 |  | 1,200 |
| 54 | 5.1.6.3 | 代码走查 | manual | 2d | 2017-11-07 A | 2017-11-08 A | 100% |  |  |  | 李丹 | 16h | 16h | 800 |  | 800 |
| 55 | 5.1.6.4 | 代码返工 | manual | 2d | 2017-11-09 A | 2017-11-10 A | 100% |  |  |  | 赵世贤 | 16h | 16h | 800 |  | 800 |
| 56 | 5.2 | 编码阶段里程碑报告编写 | manual | 1d | 2017-11-14 A | 2017-11-14 A | 100% | 2017-10-27 | 2017-10-27 | 1d | 李丹 [70%] | 8h | 8h | 400 | 400 | 400 |
| 57 | 5.3 | 编码阶段里程碑会议 | manual | 1d | 2017-11-13 A | 2017-11-13 A | 100% | 2017-10-27 | 2017-10-27 | 1d | 项目组 | 8h | 8h | 2,400 | 2,400 | 2,400 |

| ID | WBS | Task | Type | Duration | Start | Finish | Complete | Baseline start | Baseline finish | Baseline duration | Constraint | Resources | Work | Actual work | Cost | Baseline cost | Actual cost |
| --- | --- | --- | --- | --- | --- | --- | --- | --- | --- | --- | --- | --- | --- | --- | --- | --- | --- |
| 58 | 6 | **集成及测试阶段** |  | 34d | 2017-09-26 A | 2017-11-17 A | 100% | 2017-09-25 | 2017-11-06 | 25d |  |  | 288h | 288h | 20,000 | 19,600 | 20,000 |
| 59 | 6.1 | **系统测试** |  | 28d | 2017-09-26 A | 2017-11-09 A | 100% | 2017-09-25 | 2017-10-31 | 21d |  |  | 208h | 208h | 11,600 | 12,000 | 11,600 |
| 60 | 6.1.1 | 测试用例 | manual | 6d | 2017-09-26 A | 2017-10-10 A | 100% | 2017-09-25 | 2017-10-10 | 7d |  | 潘丹 | 48h | 48h | 2,400 | 4,800 | 2,400 |
| 61 | 6.1.2 | 测试用例评审 | manual | 1d | 2017-10-11 A | 2017-10-11 A | 100% | 2017-10-11 | 2017-10-11 | 1d |  | 评审组 | 8h | 8h | 1,600 | 1,600 | 1,600 |
| 62 | 6.1.3 | 第一轮测试 | manual | 12d | 2017-10-12 A | 2017-10-27 A | 100% | 2017-10-12 | 2017-10-23 | 7d |  | 潘丹 | 96h | 96h | 4,800 | 2,800 | 4,800 |
| 63 | 6.1.4 | 第二轮测试 | manual | 6d | 2017-10-30 A | 2017-11-06 A | 100% | 2017-10-26 | 2017-10-31 | 6d | start no earlier than 2017-10-30 | 潘丹 | 48h | 48h | 2,400 | 2,400 | 2,400 |
| 64 | 6.1.5 | 系统测试报告编写 | manual | 1d | 2017-11-09 A | 2017-11-09 A | 100% | 2017-10-31 | 2017-10-31 | 1d |  | 潘丹 | 8h | 8h | 400 | 400 | 400 |
| 65 | 6.2 | **用户手册** |  | 5d | 2017-11-10 A | 2017-11-16 A | 100% | 2017-11-03 | 2017-11-06 | 3d |  |  | 56h | 56h | 4,000 | 3,200 | 4,000 |
| 66 | 6.2.1 | 用户手册编写（用户安装手册，用户操作手册） | manual | 4d | 2017-11-10 A | 2017-11-15 A | 100% | 2017-11-03 | 2017-11-06 | 3d |  | 潘丹 | 32h | 32h | 1,600 | 1,200 | 1,600 |
| 67 | 6.2.2 | 用户手册评审 | manual | 1d | 2017-11-15 A | 2017-11-15 A | 100% | 2017-11-06 | 2017-11-06 | 1d |  | 评审组 | 8h | 8h | 1,600 | 1,600 | 1,600 |
| 68 | 6.2.3 | 用户手册返工 | manual | 2d | 2017-11-15 A | 2017-11-16 A | 100% | 2017-11-06 | 2017-11-06 | 1d |  | 潘丹 | 16h | 16h | 800 | 400 | 800 |
| 69 | 6.3 | 测试阶段评审会议 | manual | 1d | 2017-11-17 A | 2017-11-17 A | 100% | 2017-11-01 | 2017-11-01 | 1d |  | 评审组 | 8h | 8h | 1,600 | 1,600 | 1,600 |
| 70 | 6.4 | 编写测试阶段里程碑报告 | manual | 1d | 2017-11-17 A | 2017-11-17 A | 100% | 2017-11-02 | 2017-11-02 | 1d |  | 李丹 [50%] | 8h | 8h | 400 | 400 | 400 |
| 71 | 6.5 | 测试阶段里程碑会议 | manual | 1d | 2017-11-17 A | 2017-11-17 A | 100% | 2017-11-02 | 2017-11-02 | 1d | start no earlier than 2017-11-17 | 项目组 | 8h | 8h | 2,400 | 2,400 | 2,400 |
| 72 | 7 | **试运行** |  | 8d | 2017-11-20 A | 2017-11-29 A | 100% | 2017-11-03 | 2017-11-09 | 5d |  |  | 144h | 144h | 6,800 | 3,600 | 6,800 |
| 73 | 7.1 | **系统安装** |  | 1d | 2017-11-20 A | 2017-11-20 A | 100% | 2017-11-03 | 2017-11-03 | 1d |  |  | 16h | 16h | 800 | 800 | 800 |
| 74 | 7.1.1 | 软件安装 | manual | 1d | 2017-11-20 A | 2017-11-20 A | 100% | 2017-11-03 | 2017-11-03 | 1d |  | 赵世贤 | 8h | 8h | 400 | 400 | 400 |
| 75 | 7.1.2 | 现场培训 | manual | 1d | 2017-11-20 A | 2017-11-20 A | 100% | 2017-11-03 | 2017-11-03 | 1d |  | 潘丹 | 8h | 8h | 400 | 400 | 400 |
| 76 | 7.2 | 系统试运行 | manual | 5d | 2017-11-21 A | 2017-11-26 A | 100% | 2017-11-03 | 2017-11-09 | 5d |  | 赵世贤 | 40h | 40h | 2,000 | 2,000 | 2,000 |
| 77 | 7.3 | 试运行问题收集 | manual | 5d | 2017-11-21 A | 2017-11-26 A | 100% | 2017-11-09 | 2017-11-09 | 1d |  | 潘丹 | 40h | 40h | 2,000 | 400 | 2,000 |
| 78 | 7.4 | 试运行问题维护 | manual | 4d | 2017-11-22 A | 2017-11-27 A | 100% | 2017-11-09 | 2017-11-09 | 0d |  | 彭李雪 | 32h | 32h | 1,600 |  | 1,600 |
| 79 | 7.5 | 试运行情况汇报 | manual | 1d | 2017-11-27 A | 2017-11-27 A | 100% | 2017-11-09 | 2017-11-09 | 1d |  | 彭李雪 | 8h | 8h | 400 | 400 | 400 |
| 80 | 7.6 | 试运行报告签署 | manual | 1d | 2017-11-29 A | 2017-11-29 A | 100% | 2017-11-09 | 2017-11-09 | 1d |  | 用户代表 | 8h | 8h |  |  |  |
| 81 | 8 | **项目验收及移交** |  | 7d | 2017-11-24 A | 2017-12-04 A | 100% | 2017-11-03 | 2017-11-13 | 5d |  |  | 80h | 80h | 6,800 | 9,600 | 6,800 |
| 82 | 8.1 | **项目验收** |  | 4d | 2017-11-24 A | 2017-11-29 A | 100% | 2017-11-03 | 2017-11-13 | 5d |  |  | 40h | 40h | 3,200 | 6,000 | 3,200 |
| 83 | 8.1.1 | 验收申请 | manual | 1d | 2017-11-27 A | 2017-11-27 A | 100% | 2017-11-03 | 2017-11-09 | 1d |  | 李丹 | 8h | 8h | 400 | 400 | 400 |
| 84 | 8.1.2 | 制订验收计划、验收测试计划、验收测试用例编写 | manual | 1d | 2017-11-24 A | 2017-11-24 A | 100% | 2017-11-03 | 2017-11-09 | 2d |  | 赵世贤 | 8h | 8h | 400 | 800 | 400 |
| 85 | 8.1.3 | 验收准备 | manual | 1d | 2017-11-27 A | 2017-11-27 A | 100% | 2017-11-09 | 2017-11-09 | 2d |  | 项目组 | 8h | 8h | 2,400 | 4,800 | 2,400 |
| 86 | 8.1.4 | 验收测试、系统验收 | manual | 1d | 2017-11-28 A | 2017-11-28 A | 100% | 2017-11-09 | 2017-11-13 | 3d | start no earlier than 2017-11-28 | 用户代表 | 8h | 8h |  |  |  |
| 87 | 8.1.5 | 验收测试报告、验收报告签署 | manual | 1d | 2017-11-29 A | 2017-11-29 A | 100% | 2017-11-13 | 2017-11-13 | 1d | start no earlier than 2017-11-29 | 用户代表 | 8h | 8h |  |  |  |

| ID | WBS | Task | Type | Duration | Start | Finish | Complete | Actual start | Actual finish | Baseline start | Baseline finish | Baseline duration | Constraint | Resources | Work | Actual work | Cost | Baseline cost | Actual cost |
| --- | --- | --- | --- | --- | --- | --- | --- | --- | --- | --- | --- | --- | --- | --- | --- | --- | --- | --- | --- |
| 88 | 8.2 | **项目移交** |  | 2d | 2017-12-01 A | 2017-12-04 A | 100% |  |  | 2017-11-15 | 2017-11-15 | 1d |  |  | 16h | 16h | 800 | 800 | 800 |
| 89 | 8.2.1 | 确定移交事项 | manual | 1d | 2017-12-01 A | 2017-12-01 A | 100% |  |  | 2017-11-15 | 2017-11-15 | 1d |  | 赵世贤 [50%] | 8h | 8h | 400 | 400 | 400 |
| 90 | 8.2.2 | 移交项目技术资料 | manual | 1d | 2017-12-04 A | 2017-12-04 A | 100% |  |  | 2017-11-15 | 2017-11-15 | 1d |  | 赵世贤 [50%] | 8h | 8h | 400 | 400 | 400 |
| 91 | 8.3 | 编写验收阶段里程碑报告 | manual | 1d | 2017-12-04 A | 2017-12-04 A | 100% |  |  | 2017-11-14 | 2017-11-14 | 1d |  | 李丹 [50%] | 8h | 8h | 400 | 400 | 400 |
| 92 | 8.4 | 验收阶段里程碑会议 | manual | 1d | 2017-12-04 A | 2017-12-04 A | 100% |  |  | 2017-11-14 | 2017-11-14 | 1d |  | 项目组; 用户代表 | 16h | 16h | 2,400 | 2,400 | 2,400 |
| 93 | 9 | **结项** |  | 1d | 2017-12-05 A | 2017-12-05 A | 100% |  |  | 2017-11-15 | 2017-11-15 | 1d |  |  | 16h | 16h | 2,800 | 2,800 | 2,800 |
| 94 | 9.1 | 项目经理提交项目总结报告 | manual | 1d | 2017-12-05 A | 2017-12-05 A | 100% |  |  | 2017-11-15 | 2017-11-15 | 1d |  | 李丹 [50%] | 8h | 8h | 400 | 400 | 400 |
| 95 | 9.2 | 召开项目总结会议 | manual | 1d | 2017-12-05 A | 2017-12-05 A | 100% |  |  | 2017-11-15 | 2017-11-15 | 1d |  | 项目组 | 8h | 8h | 2,400 | 2,400 | 2,400 |
| 96 | 10 | **项目跟踪与监控** |  | 63d | 2017-09-01 A | 2017-12-05 A | 100% |  |  | 2017-09-01 | 2017-11-15 | 46d |  |  | 120h | 120h | 15,200 | 18,000 | 15,200 |
| 97 | 10.1 | **项目例会** |  | 63d | 2017-09-01 A | 2017-12-05 A | 100% |  |  | 2017-09-08 | 2017-11-15 | 41d |  |  | 48h | 48h | 12,000 | 16,800 | 12,000 |
| 98 | 10.1.1 | 项目例会 1（风险、度量等） | manual | 1d | 2017-09-01 A | 2017-09-01 A | 100% |  |  | 2017-09-08 | 2017-09-08 | 1d |  | 项目组 | 8h | 8h |  |  |  |
| 99 | 10.1.2 | 项目例会 2（风险、度量等） | manual | 1d | 2017-09-15 A | 2017-09-15 A | 100% |  |  | 2017-09-15 | 2017-09-15 | 0d | start no earlier than 2017-09-15 | 项目组 | 8h | 8h | 2,400 |  | 2,400 |
| 100 | 10.1.3 | 项目例会 3（风险、度量等） | manual | 1d | 2017-10-16 A | 2017-10-16 A | 100% |  |  | 2017-09-22 | 2017-09-22 | 1d |  | 项目组 | 8h | 8h | 2,400 | 2,400 | 2,400 |
| 101 | 10.1.4 | 项目例会 4（风险、度量等） | manual | 1d | 2017-11-01 A | 2017-11-01 A | 100% |  |  | 2017-09-29 | 2017-09-29 | 1d |  | 项目组 | 8h | 8h | 2,400 | 2,400 | 2,400 |
| 102 | 10.1.5 | 项目例会 5（风险、度量等） | manual | 1d | 2017-11-17 A | 2017-11-17 A | 100% |  |  |  |  |  |  | 项目组 | 8h | 8h | 2,400 |  | 2,400 |
| 103 | 10.1.6 | 项目例会 6（风险、度量等） | manual | 1d | 2017-12-05 A | 2017-12-05 A | 100% |  |  | 2017-10-13 | 2017-10-13 | 1d |  | 项目组 | 8h | 8h | 2,400 | 2,400 | 2,400 |
| 104 | 10.2 | **项目管理、需求分析** |  | 26d | 2017-09-15 A | 2017-10-27 A | 100% |  |  | 2017-09-15 | 2017-10-27 | 26d |  |  | 32h | 32h | 1,200 | 1,200 | 1,200 |
| 105 | 10.2.1 | 需求、项目管理一 | manual | 1d | 2017-09-15 A | 2017-09-15 A | 100% |  |  | 2017-09-15 | 2017-09-15 | 1d |  | 李丹 | 8h | 8h |  |  |  |
| 106 | 10.2.2 | 需求、项目管理二 | manual | 1d | 2017-09-29 A | 2017-09-29 A | 100% |  |  | 2017-09-29 | 2017-09-29 | 1d |  | 李丹 | 8h | 8h | 400 | 400 | 400 |
| 107 | 10.2.3 | 需求、项目管理三 | manual | 1d | 2017-10-13 A | 2017-10-13 A | 100% |  |  | 2017-10-13 | 2017-10-13 | 1d |  | 李丹 | 8h | 8h | 400 | 400 | 400 |
| 108 | 10.2.4 | 需求、项目管理四 | manual | 1d | 2017-10-27 A | 2017-10-27 A | 100% |  |  | 2017-10-27 | 2017-10-27 | 1d |  | 李丹 | 8h | 8h | 400 | 400 | 400 |
| 109 | 10.3 | QA工作 | manual | 57d | 2017-09-01 A | 2017-11-25 A | 100% |  |  | 2017-09-01 | 2017-11-15 | 46d |  |  |  |  |  |  |  |
| 110 | 10.4 | **CM工作** |  | 44d | 2017-09-20 | 2017-11-25 | 100% | 2017-09-22 | 2017-12-05 | 2017-09-01 | 2017-11-15 | 46d |  |  | 40h | 40h | 2,000 |  | 2,000 |
| 111 | 10.4.1 | **配置报告** |  | 48d | 2017-09-22 A | 2017-12-05 A | 100% |  |  | 2017-09-20 | 2017-12-15 |  |  |  | 40h | 40h | 2,000 |  | 2,000 |
| 112 | 10.4.1.1 | 需求阶段CM活动报告和基线管理 | manual | 1d | 2017-09-22 A | 2017-09-22 A | 100% |  |  | 2017-09-21 | 2017-09-21 |  |  | 胡威 | 8h | 8h | 400 |  | 400 |
| 113 | 10.4.1.2 | 设计阶段CM活动报告和基线管理 | manual | 1d | 2017-09-25 A | 2017-09-25 A | 100% |  |  | 2017-09-26 | 2017-09-26 | 0d |  | 胡威 | 8h | 8h | 400 |  | 400 |
| 114 | 10.4.1.3 | 实现阶段CM活动报告和基线管理 | manual | 1d | 2017-11-14 A | 2017-11-14 A | 100% |  |  | 2017-10-30 | 2017-10-30 |  |  | 胡威 | 8h | 8h | 400 |  | 400 |
| 115 | 10.4.1.4 | 测试阶段CM活动报告和基线管理 | manual | 1d | 2017-11-17 A | 2017-11-17 A | 100% |  |  | 2017-11-03 | 2017-11-03 |  |  | 胡威 | 8h | 8h | 400 |  | 400 |
| 116 | 10.4.1.5 | 验收阶段CM活动报告和基线管理 | manual | 1d | 2017-12-05 A | 2017-12-05 A | 100% |  |  | 2017-11-15 | 2017-12-15 |  |  | 胡威 | 8h | 8h | 400 |  | 400 |
